# 2016_Spring_I2MAP_EngineeringScheduleKRR_3_8_16

How a schedule from MS Project changed from version to version. A marks actual dates.

## Version 1 (saved 2016-03-08, file 2016_Spring_I2MAP_EngineeringScheduleKRR_3_8_16.mpp)

| ID | WBS | Task | Duration | Start | Finish | Predecessors | Complete | Total float | Constraint |
| --- | --- | --- | --- | --- | --- | --- | --- | --- | --- |
| 1 | 1 | **Original dome design evaluation (Round 2)** | 54.5d? | 2016-02-05 A | 2016-04-21 |  | 34% | 9.83d |  |
| 2 |  | Evaluate possible causes of prior failure | 4d? | 2016-02-05 A | 2016-02-10 A |  | 100% |  | finish no earlier than 2016-02-10 |
| 3 |  | Re-run simulations to verify results of tests 1 & 2 | 12.5d? | 2016-02-15 A | 2016-03-02 A | 2 | 100% |  | start no earlier than 2016-02-15 |
| 4 |  | Redesign solid model of dome support | 9.5d | 2016-03-03 A | 2016-03-16 | 3 | 32% | 9.83d | start no earlier than 2016-03-03 |
| 5 |  | Perform complete FEA analysis of design #3 | 5d | 2016-03-16 | 2016-03-23 | 4 |  | 9.83d | start no earlier than 2016-03-07 |
| 6 |  | Perform alternate FEA analysis of design #3 | 5d | 2016-03-16 | 2016-03-23 | 4 |  | 9.83d | start no earlier than 2016-03-07 |
| 7 |  | Meet and evaluate new design options | 0d | 2016-03-23 | 2016-03-23 | 6, 5 |  | 9.83d | start no earlier than 2016-03-07 |
| 8 |  | Complete fabrication drawings | 3d | 2016-03-23 | 2016-03-28 | 7 |  | 9.83d | start no earlier than 2016-03-07 |
| 9 |  | Fabricate new dome support | 10d | 2016-03-28 | 2016-04-11 | 8 |  | 9.83d | start no earlier than 2016-03-07 |
| 10 |  | Prepare dome #3 and test rig for test | 4d | 2016-04-11 | 2016-04-15 | 9 |  | 9.83d | finish no earlier than 2016-02-16 |
| 11 |  | Pressure test of domes at Pt. Hueneme | 4d | 2016-04-15 | 2016-04-21 | 10 |  | 9.83d | finish no earlier than 2016-02-22 |
| 12 |  | Review of results and determine how to proceed | 0d | 2016-04-21 | 2016-04-21 | 11 |  | 9.83d | start no earlier than 2016-03-07 |
| 13 | 2 | **Lab Testing** | 49d? | 2016-02-04 A | 2016-04-13 |  | 11% | 23d |  |
| 14 | 2.1 | **CTD System** | 24d? | 2016-02-04 A | 2016-03-08 |  | 45% | 48d |  |
| 15 |  | Full CTD test set-up | 1.5d? | 2016-02-04 A | 2016-02-05 A |  | 100% |  | start no earlier than 2016-02-04 |
| 16 |  | Document CTD data load path | 0.1d? | 2016-02-23 A | 2016-02-23 A | 15 | 100% |  | start no earlier than 2016-02-23 |
| 17 |  | Config file for ???? | 1d? | 2016-03-08 | 2016-03-08 |  |  | 48d | start no earlier than 2016-03-08 |
| 18 |  | End-to-end CTD data verification | 1d | 2016-03-07 | 2016-03-07 | 16 |  | 39.33d | start no earlier than 2016-03-07 |
| 19 | 2.2 | **Verify camera Settings** | 1.46d? | 2016-03-07 | 2016-03-08 |  |  | 38.88d |  |
| 20 |  | Test persistance over power cycle | 1.46d? | 2016-03-07 | 2016-03-08 |  |  | 38.88d | start no earlier than 2016-03-07 |
| 21 |  | Install new camera firmware | 0.83d | 2016-03-07 | 2016-03-07 |  |  | 39.5d | start no earlier than 2016-03-07 |
| 22 | 2.3 | **Camera Iris and Lighting Control** | 1d? | 2016-03-08 | 2016-03-08 |  |  | 38.33d |  |
| 23 |  | Verify light switching and intensity | 1d | 2016-03-08 | 2016-03-08 |  |  | 38.33d | start no earlier than 2016-03-07 |
| 24 |  | Verify iris control and no light interference | 1d? | 2016-03-08 | 2016-03-08 |  |  | 38.33d | start no earlier than 2016-03-07 |
| 25 | 2.4 | **Mission script development** | 26d | 2016-03-08 | 2016-04-13 |  |  | 0d |  |
| 26 |  | Mission script development | 10d | 2016-03-08 | 2016-03-21 |  |  | 16d | start no earlier than 2016-03-07 |
| 27 |  | Mission script review | 0d | 2016-04-13 | 2016-04-13 | 26 |  | 0d | must start on 2016-04-13 |
| 28 | 2.5 | **Misc. functions** | 1d? | 2016-03-08 A | 2016-03-08 |  | 17% | 38.33d |  |
| 29 |  | Test light brightness and current | 0.5d | 2016-03-08 | 2016-03-08 |  |  | 38.83d | start no earlier than 2016-03-07 |
| 30 |  | Data logging | 1d? | 2016-03-08 | 2016-03-08 |  |  | 38.33d | start no earlier than 2016-03-07 |
| 31 |  | Water alarm abort verification | 1d? | 2016-03-08 A | 2016-03-08 |  | 75% | 38.33d | start no earlier than 2016-03-07 |
| 32 |  | Verify camera temperature reading | 1d? | 2016-03-08 | 2016-03-08 |  |  | 38.33d | start no earlier than 2016-03-07 |
| 33 |  | Debug video peak and mean readings | 1d? | 2016-03-08 | 2016-03-08 |  |  | 38.33d | start no earlier than 2016-03-07 |
| 34 |  | Lab unit testing complete | 0d | 2016-03-08 | 2016-03-08 | 31, 30, 24, 23, 20, 18, 32, 33, 29, 21 |  | 38.33d | start no earlier than 2016-02-02 |
| 35 |  | VM closed loop simulation testing | 3d | 2016-04-13 | 2016-04-15 | 27, 34 |  | 13.33d | start no earlier than 2016-02-02 |
| 36 |  | Code freeze | 0d | 2016-04-15 | 2016-04-15 | 35 |  | 13.33d | start no earlier than 2016-02-02 |
| 37 |  | All lab testing complete | 0d | 2016-04-15 | 2016-04-15 | 36 |  | 13.33d | start no earlier than 2016-02-02 |
| 38 |  | Assemble complete camera housing | 1.67d | 2016-04-21 | 2016-04-25 | 12, 37 |  | 9.83d | start no earlier than 2016-03-07 |
| 39 | 7 | **Tank testing with full vehicle running mission script** | 3d? | 2016-05-09 | 2016-05-11 |  |  | 0d |  |
| 40 |  | Assemble full AUV system | 1d | 2016-05-09 | 2016-05-09 | 38 |  | 0d | must start on 2016-05-09 |
| 41 |  | Verify mission scripts | 1d | 2016-05-10 | 2016-05-10 | 40 |  | 1d | start no earlier than 2016-02-02 |
| 42 |  | Confirm all camera operations | 1d | 2016-05-10 | 2016-05-10 | 40 |  | 1d | start no earlier than 2016-02-02 |
| 43 |  | Verify lighting is optimized | 1d? | 2016-05-11 | 2016-05-11 | 40 |  | 0d | start no earlier than 2016-05-11 |
| 44 |  | Ballast and Trim | 1d? | 2016-05-11 | 2016-05-11 | 40 |  | 0d | start no earlier than 2016-05-11 |
| 45 |  | Tank testing complete | 0d | 2016-05-11 | 2016-05-11 | 44, 42, 43, 41 |  | 0d | start no earlier than 2016-02-02 |
| 46 |  | Load AUV for cruise | 1d | 2016-05-12 | 2016-05-12 | 45 |  | 0d | must start on 2016-05-12 |
| 47 |  | Cruise for transect mission | 0d | 2016-05-16 | 2016-05-16 | 46 |  | 0d | must start on 2016-05-16 |

## Version 2 (saved 2016-03-08, file 2016_Spring_I2MAP_EngineeringSchedule.mpp)

Last finish stays 2016-05-16.

Removed: 17 Config file for ????

Changed:

| ID | Task | Start | Finish | Duration | Complete | Total float |
| --- | --- | --- | --- | --- | --- | --- |
| 13 | **Lab Testing** |  |  |  | 11% → 7% | 23d → 13.33d |
| 14 | **CTD System** |  | 2016-03-08 → 2016-03-07 (-1d) | 24d? → 23d? | 45% → 62% | 48d → 39.33d |
| 27 | **Misc. functions** | 2016-03-08 A → 2016-03-08 |  |  | 17% → 0% |  |
| 30 | Water alarm abort verification | 2016-03-08 A → 2016-03-08 |  |  | 75% → 0% |  |

## Version 3 (saved 2016-03-23, file 2016_Spring_I2MAP_EngineeringScheduleKRR_3_23_16.mpp)

Last finish stays 2016-05-16. Complete tasks 4 → 5.

Added:

| ID | Task | Duration | Start | Finish | Constraint |
| --- | --- | --- | --- | --- | --- |
| 17 | Config file for CTD sensors | 1d? | 2016-03-18 A | 2016-03-18 A | finish no earlier than 2016-03-18 |

Changed:

| ID | Task | Start | Finish | Duration | Complete | Total float | Predecessors | Other |
| --- | --- | --- | --- | --- | --- | --- | --- | --- |
| 1 | **Original dome design evaluation (Round 2)** |  | 2016-04-21 → 2016-05-06 (+15d) | 54.5d? → 66d? | 34% → 45% | 9.83d → 0.33d |  |  |
| 4 | Redesign solid model of dome support |  | 2016-03-16 → 2016-03-23 (+7d) | 9.5d → 15d | 32% → 75% | 9.83d → -3d |  |  |
| 5 | Perform complete FEA analysis of design #3 | 2016-03-16 → 2016-03-21 (+5d) | 2016-03-23 → 2016-03-25 (+2d) |  |  | 9.83d → -3d |  | constraint start no earlier than 2016-03-07 → start no later than 2016-03-21; resources François Cazenave [60%] → François Cazenave |
| 6 | Perform alternate FEA analysis of design #3 | 2016-03-16 → 2016-04-04 (+19d) | 2016-03-23 → 2016-04-08 (+16d) |  |  | 9.83d → 0.33d | 4 → 4, 5 | constraint start no earlier than 2016-03-07 → start no earlier than 2016-04-04; resources Jon Erickson [60%] → Jon Erickson |
| 7 | Meet and evaluate new design options | 2016-03-23 → 2016-04-08 (+16d) | 2016-03-23 → 2016-04-08 (+16d) |  |  | 24.5d → 0.33d |  |  |
| 8 | Complete fabrication drawings | 2016-03-23 → 2016-04-11 (+19d) | 2016-03-28 → 2016-04-13 (+16d) |  |  | 9.83d → 0.33d |  |  |
| 9 | Fabricate new dome support | 2016-03-28 → 2016-04-14 (+17d) | 2016-04-11 → 2016-04-27 (+16d) |  |  | 9.83d → 0.33d |  |  |
| 10 | Prepare dome #3 and test rig for test | 2016-04-11 → 2016-04-28 (+17d) | 2016-04-15 → 2016-05-03 (+18d) |  |  | 9.83d → 0.33d |  |  |
| 11 | Pressure test of domes at Pt. Hueneme | 2016-04-15 → 2016-05-04 (+19d) | 2016-04-21 → 2016-05-06 (+15d) | 4d → 3d |  | 9.83d → 0.33d |  |  |
| 12 | Review of results and determine how to proceed | 2016-04-21 → 2016-05-06 (+15d) | 2016-04-21 → 2016-05-06 (+15d) |  |  | 9.83d → 0.33d |  |  |
| 13 | **Lab Testing** |  | 2016-04-13 → 2016-05-09 (+26d) | 49d? → 68d? | 7% → 15% | 13.33d → 0d |  |  |
| 14 | **CTD System** |  | 2016-03-07 → 2016-04-05 (+29d) | 23d? → 44d? | 62% → 72% | 39.33d → 20.33d |  |  |
| 18 | End-to-end CTD data verification | 2016-03-07 → 2016-04-05 (+29d) | 2016-03-07 → 2016-04-05 (+29d) |  |  | 39.33d → 20.33d |  | constraint start no earlier than 2016-03-07 → start no earlier than 2016-04-05 |
| 19 | **Verify camera Settings** | 2016-03-07 → 2016-03-28 (+21d) | 2016-03-08 → 2016-03-29 (+21d) |  |  | 38.88d → 25.88d |  |  |
| 20 | Test persistance over power cycle | 2016-03-07 → 2016-03-28 (+21d) | 2016-03-08 → 2016-03-29 (+21d) |  |  | 38.88d → 25.88d |  | constraint start no earlier than 2016-03-07 → start no earlier than 2016-03-28 |
| 21 | Install new camera firmware | 2016-03-07 → 2016-03-28 (+21d) | 2016-03-07 → 2016-03-28 (+21d) |  |  | 39.5d → 26.5d |  | constraint start no earlier than 2016-03-07 → start no earlier than 2016-03-28 |
| 22 | **Camera Iris and Lighting Control** | 2016-03-08 → 2016-04-04 (+27d) | 2016-03-08 → 2016-04-04 (+27d) |  |  | 38.33d → none |  |  |
| 23 | Verify light switching and intensity | 2016-03-08 → 2016-04-04 (+27d) | 2016-03-08 → 2016-04-04 (+27d) |  |  | 38.33d → 21.33d |  | constraint start no earlier than 2016-03-07 → start no earlier than 2016-04-04 |
| 24 | Verify iris control and no light interference | 2016-03-08 → 2016-04-04 (+27d) | 2016-03-08 → 2016-04-04 (+27d) |  |  | 38.33d → 21.33d |  | constraint start no earlier than 2016-03-07 → start no earlier than 2016-04-04 |
| 25 | **Mission script development** | 2016-03-08 → 2016-04-04 (+27d) | 2016-04-13 → 2016-05-09 (+26d) |  |  | 0d → none |  |  |
| 26 | Mission script development | 2016-03-08 → 2016-04-04 (+27d) | 2016-03-21 → 2016-04-15 (+25d) |  |  | 16d → 12.33d |  | constraint start no earlier than 2016-03-07 → start no earlier than 2016-04-04 |
| 27 | Mission script review | 2016-04-13 → 2016-04-18 (+5d) | 2016-04-13 → 2016-04-18 (+5d) |  |  | 0d → 12.33d |  | constraint must start on 2016-04-13 → start no earlier than 2016-04-18 |
| 28 | **Misc. functions** | 2016-03-08 → 2016-04-05 A (+28d) | 2016-03-08 → 2016-05-02 (+55d) | 1d? → 20d? | 0% → 17% | 38.33d → none |  |  |
| 29 | Test light brightness and current | 2016-03-08 → 2016-04-05 (+28d) | 2016-03-08 → 2016-04-05 (+28d) |  |  | 38.83d → 20.83d |  | constraint start no earlier than 2016-03-07 → start no earlier than 2016-04-05 |
| 30 | Data logging | 2016-03-08 → 2016-04-05 (+28d) | 2016-03-08 → 2016-04-05 (+28d) |  |  | 38.33d → 20.33d |  | constraint start no earlier than 2016-03-07 → start no earlier than 2016-04-05 |
| 31 | Water alarm abort verification | 2016-03-08 → 2016-04-05 A (+28d) | 2016-03-08 → 2016-04-05 (+28d) |  | 0% → 75% | 38.33d → 20.33d |  |  |
| 32 | Verify camera temperature reading | 2016-03-08 → 2016-04-05 (+28d) | 2016-03-08 → 2016-04-05 (+28d) |  |  | 38.33d → 20.33d |  | constraint start no earlier than 2016-03-07 → start no earlier than 2016-04-05 |
| 33 | Debug video peak and mean readings | 2016-03-08 → 2016-04-05 (+28d) | 2016-03-08 → 2016-04-05 (+28d) |  |  | 38.33d → 20.33d |  | constraint start no earlier than 2016-03-07 → start no earlier than 2016-04-05 |
| 34 | Lab unit testing complete | 2016-03-08 → 2016-04-05 (+28d) | 2016-03-08 → 2016-04-05 (+28d) |  |  | 38.33d → 20.33d |  | constraint start no earlier than 2016-02-02 → start no earlier than 2016-04-05 |
| 35 | VM closed loop simulation testing | 2016-04-13 → 2016-04-18 (+5d) | 2016-04-15 → 2016-04-20 (+5d) |  |  | 13.33d → 12.33d |  |  |
| 36 | Code freeze | 2016-04-15 → 2016-04-20 (+5d) | 2016-04-15 → 2016-04-20 (+5d) |  |  | 13.33d → 12.33d |  |  |
| 37 | All lab testing complete | 2016-04-15 → 2016-04-20 (+5d) | 2016-04-15 → 2016-04-20 (+5d) |  |  | 13.33d → 12.33d |  |  |
| 38 | Assemble complete camera housing | 2016-04-21 → 2016-05-09 (+18d) | 2016-04-25 → 2016-05-10 (+15d) |  |  | 9.83d → 0.33d |  | constraint start no earlier than 2016-03-07 → start no earlier than 2016-05-01 |
| 39 | **Tank testing with full vehicle running mission script** | 2016-05-09 → 2016-05-11 (+2d) | 2016-05-11 → 2016-05-13 (+2d) |  |  | 0d → none |  |  |
| 40 | Assemble full AUV system | 2016-05-09 → 2016-05-11 (+2d) | 2016-05-09 → 2016-05-11 (+2d) |  |  |  |  | constraint must start on 2016-05-09 → none |
| 41 | Verify mission scripts | 2016-05-10 → 2016-05-12 (+2d) | 2016-05-10 → 2016-05-12 (+2d) |  |  | 1d → 0d |  |  |
| 42 | Confirm all camera operations | 2016-05-10 → 2016-05-12 (+2d) | 2016-05-10 → 2016-05-12 (+2d) |  |  | 1d → 0d |  |  |
| 43 | Verify lighting is optimized | 2016-05-11 → 2016-05-12 (+1d) | 2016-05-11 → 2016-05-12 (+1d) |  |  |  |  |  |
| 44 | Ballast and Trim | 2016-05-11 → 2016-05-12 (+1d) | 2016-05-11 → 2016-05-12 (+1d) |  |  |  |  |  |
| 45 | Tank testing complete | 2016-05-11 → 2016-05-12 (+1d) | 2016-05-11 → 2016-05-12 (+1d) |  |  |  |  |  |
| 46 | Load AUV for cruise | 2016-05-12 → 2016-05-13 (+1d) | 2016-05-12 → 2016-05-13 (+1d) |  |  |  |  | constraint must start on 2016-05-12 → none |

## Version 4 (saved 2016-03-30, file 2016_Spring_I2MAP_EngineeringScheduleKRR_3_29_16.mpp)

Last finish stays 2016-05-16.

Added:

| ID | Task | Duration | Start | Finish | Constraint | Resources |
| --- | --- | --- | --- | --- | --- | --- |
| 10 | Domes (2) away for seat leveling and polishing | 24d? | 2016-03-22 | 2016-04-22 | start no earlier than 2016-03-22 | Chinese Shop |

Changed:

| ID | Task | Start | Finish | Duration | Complete | Total float | Predecessors | Other |
| --- | --- | --- | --- | --- | --- | --- | --- | --- |
| 1 | **Original dome design evaluation (Round 2)** |  | 2016-05-06 → 2016-05-05 (-1d) | 66d? → 65d? | 45% → 31% | 0.33d → 1.33d |  |  |
| 6 | Perform alternate FEA analysis of design #3 | 2016-04-04 → 2016-03-28 (-7d) | 2016-04-08 → 2016-04-05 (-3d) | 5d → 7d |  | 0.33d → 1.33d |  | constraint start no earlier than 2016-04-04 → start no earlier than 2016-03-28 |
| 7 | Meet and evaluate new design options | 2016-04-08 → 2016-04-05 (-3d) | 2016-04-08 → 2016-04-05 (-3d) |  |  | 0.33d → 1.33d |  |  |
| 8 | Complete fabrication drawings | 2016-04-11 → 2016-04-06 (-5d) | 2016-04-13 → 2016-04-08 (-5d) |  |  | 0.33d → 1.33d |  | constraint start no earlier than 2016-03-07 → finish no earlier than 2016-04-01 |
| 9 | Fabricate new dome support | 2016-04-14 → 2016-04-11 (-3d) | 2016-04-27 → 2016-04-22 (-5d) |  |  | 0.33d → 1.33d |  | constraint start no earlier than 2016-03-07 → start no earlier than 2016-04-11 |
| 11 | Prep domes #3 & 4 and test rig for Pressure test | 2016-04-28 → 2016-04-25 (-3d) | 2016-05-03 → 2016-04-29 (-4d) | 4d → 5d |  | 0.33d → 1.33d | 9 → 9, 10 | was named Prepare dome #3 and test rig for test |
| 12 | Pressure test of domes at Pt. Hueneme | 2016-05-04 → 2016-05-02 (-2d) | 2016-05-06 → 2016-05-05 (-1d) | 3d → 4d |  | 0.33d → 1.33d |  |  |
| 13 | Review of results and determine how to proceed | 2016-05-06 → 2016-05-05 (-1d) | 2016-05-06 → 2016-05-05 (-1d) |  |  | 0.33d → 1.33d |  |  |
| 28 | Mission script review | 2016-04-18 → 2016-04-26 (+8d) | 2016-04-18 → 2016-04-26 (+8d) |  |  | 12.33d → 6.33d |  | constraint start no earlier than 2016-04-18 → start no earlier than 2016-04-26 |
| 36 | VM closed loop simulation testing | 2016-04-18 → 2016-04-26 (+8d) | 2016-04-20 → 2016-04-28 (+8d) |  |  | 12.33d → 6.33d |  |  |
| 37 | Code freeze | 2016-04-20 → 2016-04-28 (+8d) | 2016-04-20 → 2016-04-28 (+8d) |  |  | 12.33d → 6.33d |  | constraint start no earlier than 2016-02-02 → start no earlier than 2016-04-26 |
| 38 | All lab testing complete | 2016-04-20 → 2016-04-28 (+8d) | 2016-04-20 → 2016-04-28 (+8d) |  |  | 12.33d → 6.33d |  |  |
| 39 | Assemble complete camera housing | 2016-05-09 → 2016-05-06 (-3d) | 2016-05-10 → 2016-05-09 (-1d) |  |  | 0.33d → 1.33d |  |  |
| 40 | **Tank testing with full vehicle running mission script** | 2016-05-11 → 2016-05-09 (-2d) | 2016-05-13 → 2016-05-11 (-2d) |  |  |  |  |  |
| 41 | Assemble full AUV system | 2016-05-11 → 2016-05-09 (-2d) | 2016-05-11 → 2016-05-10 (-1d) |  |  | 0d → 1.33d |  |  |
| 42 | Verify mission scripts | 2016-05-12 → 2016-05-10 (-2d) | 2016-05-12 → 2016-05-11 (-1d) |  |  | 0d → 1.33d |  |  |
| 43 | Confirm all camera operations | 2016-05-12 → 2016-05-10 (-2d) | 2016-05-12 → 2016-05-11 (-1d) |  |  | 0d → 1.33d |  |  |
| 44 | Verify lighting is optimized | 2016-05-12 → 2016-05-11 (-1d) | 2016-05-12 → 2016-05-11 (-1d) |  |  | 0d → 1d |  |  |
| 45 | Ballast and Trim | 2016-05-12 → 2016-05-11 (-1d) | 2016-05-12 → 2016-05-11 (-1d) |  |  | 0d → 1d |  |  |
| 46 | Tank testing complete | 2016-05-12 → 2016-05-11 (-1d) | 2016-05-12 → 2016-05-11 (-1d) |  |  | 0d → 1d |  |  |
| 47 | Load AUV for cruise | 2016-05-13 → 2016-05-12 (-1d) | 2016-05-13 → 2016-05-12 (-1d) |  |  | 0d → 1d |  |  |

## Version 5 (saved 2016-04-19, file 2016_Spring_I2MAP_EngineeringScheduleKRR_4_19_16.mpp)

Last finish 2016-05-16 → 2016-12-12 (+210d). Complete tasks 5 → 7.

Added:

| ID | Task | Duration | Start | Finish | Predecessors | Constraint | Resources |
| --- | --- | --- | --- | --- | --- | --- | --- |
| 10 | Prepare 1 dome and support for pressure testing | 2d | 2016-05-03 | 2016-05-04 | 9 |  | François Cazenave [60%]; Kim Reisenbichler |
| 11 | Pressure test of dome at Pt. Hueneme | 2d | 2016-05-05 | 2016-05-06 | 10 |  | François Cazenave [60%] |
| 13 | Fabricate additional dome support | 6d | 2016-06-13 | 2016-06-20 |  | start no earlier than 2016-06-13 |  |
| 52 | Backup Cruise date | 0d | 2016-06-01 | 2016-06-01 |  | start no earlier than 2016-06-01 |  |
| 53 | 2nd transect intercomparison cruise | 0d | 2016-06-06 | 2016-06-06 |  | start no earlier than 2016-06-06 |  |
| 54 | 3rd transect intercomparison cruise | 0d | 2016-09-15 | 2016-09-15 |  | start no earlier than 2016-09-15 |  |
| 55 | 4th transect intercomparison cruise | 0d | 2016-11-07 | 2016-11-07 |  | start no earlier than 2016-11-07 |  |
| 56 | 5th transect intercomparison cruise | 0d | 2016-12-12 | 2016-12-12 |  | start no earlier than 2016-12-12 |  |

Changed:

| ID | Task | Start | Finish | Duration | Complete | Total float | Predecessors | Other |
| --- | --- | --- | --- | --- | --- | --- | --- | --- |
| 1 | **Original dome design evaluation (Round 2)** |  | 2016-05-05 → 2016-06-28 (+54d) | 65d? → 103d? | 31% → 37% | 1.33d → 118d |  |  |
| 6 | Perform alternate FEA analysis of design #3 | 2016-03-28 A | 2016-04-05 A |  | 0% → 100% | 1.33d → none |  |  |
| 8 | Complete fabrication drawings | 2016-04-06 A | 2016-04-08 A |  | 0% → 100% | 1.33d → none |  |  |
| 9 | Fabricate new dome support | 2016-04-11 → 2016-04-26 (+15d) | 2016-04-22 → 2016-05-02 (+10d) | 10d → 5d |  | 1.33d → 0.33d |  | constraint start no earlier than 2016-04-11 → start no earlier than 2016-04-26 |
| 12 | Domes (2) away for seat leveling and polishing |  | 2016-04-22 → 2016-05-09 (+17d) | 24d? → 35d |  |  |  |  |
| 14 | Prep dome #4 and test rig for Pressure test | 2016-04-25 → 2016-06-21 (+57d) | 2016-04-29 → 2016-06-22 (+54d) | 5d → 2d |  | 1.33d → 118d | 9, 12 → 12, 13 | was named Prep domes #3 & 4 and test rig for Pressure test; constraint finish no earlier than 2016-02-16 → start no earlier than 2016-05-23 |
| 15 | Extensive pressure test of domes #3 & #4 at Pt. Hueneme | 2016-05-02 → 2016-06-23 (+52d) | 2016-05-05 → 2016-06-28 (+54d) |  |  | 1.33d → 118d |  | was named Pressure test of domes at Pt. Hueneme |
| 16 | Review of results and determine how to proceed | 2016-05-05 → 2016-06-28 (+54d) | 2016-05-05 → 2016-06-28 (+54d) |  |  | 1.33d → 118d |  |  |
| 17 | **Lab Testing** |  | 2016-05-09 → 2016-05-12 (+3d) | 68d? → 71d? |  |  |  |  |
| 18 | **CTD System** |  | 2016-04-05 → 2016-04-22 (+17d) | 44d? → 57d? |  | 20.33d → 7.33d |  |  |
| 22 | End-to-end CTD data verification | 2016-04-05 → 2016-04-22 (+17d) | 2016-04-05 → 2016-04-22 (+17d) |  |  | 20.33d → 7.33d |  | constraint start no earlier than 2016-04-05 → start no earlier than 2016-04-22 |
| 23 | **Verify camera Settings** | 2016-03-28 → 2016-04-20 (+23d) | 2016-03-29 → 2016-04-21 (+23d) |  |  | 25.88d → 8.88d |  |  |
| 24 | Test persistance over power cycle | 2016-03-28 → 2016-04-20 (+23d) | 2016-03-29 → 2016-04-21 (+23d) |  |  | 25.88d → 8.88d |  | constraint start no earlier than 2016-03-28 → start no earlier than 2016-04-20 |
| 25 | Install new camera firmware | 2016-03-28 → 2016-04-20 (+23d) | 2016-03-28 → 2016-04-20 (+23d) |  |  | 26.5d → 9.5d |  | constraint start no earlier than 2016-03-28 → start no earlier than 2016-04-20 |
| 26 | **Camera Iris and Lighting Control** | 2016-04-04 → 2016-04-20 (+16d) | 2016-04-04 → 2016-04-20 (+16d) |  |  |  |  |  |
| 27 | Verify light switching and intensity | 2016-04-04 → 2016-04-20 (+16d) | 2016-04-04 → 2016-04-20 (+16d) |  |  | 21.33d → 9.33d |  | constraint start no earlier than 2016-04-04 → start no earlier than 2016-04-20 |
| 28 | Verify iris control and no light interference | 2016-04-04 → 2016-04-20 (+16d) | 2016-04-04 → 2016-04-20 (+16d) |  |  | 21.33d → 9.33d |  | constraint start no earlier than 2016-04-04 → start no earlier than 2016-04-20 |
| 29 | **Mission script development** | 2016-04-04 → 2016-04-20 (+16d) | 2016-05-09 → 2016-05-03 (-6d) | 26d → 10d |  |  |  |  |
| 30 | Mission script development | 2016-04-04 → 2016-04-20 (+16d) | 2016-04-15 → 2016-05-03 (+18d) |  |  | 12.33d → 0.33d |  | constraint start no earlier than 2016-04-04 → start no earlier than 2016-04-20 |
| 31 | Mission script review | 2016-04-26 → 2016-05-03 (+7d) | 2016-04-26 → 2016-05-03 (+7d) |  |  | 6.33d → 0.33d |  | constraint start no earlier than 2016-04-26 → start no earlier than 2016-04-20 |
| 32 | **Misc. functions** | 2016-04-05 A → 2016-04-22 A (+17d) | 2016-05-02 → 2016-05-12 (+10d) | 20d? → 15d |  |  |  |  |
| 33 | Test light brightness and current | 2016-04-05 → 2016-04-22 (+17d) | 2016-04-05 → 2016-04-22 (+17d) |  |  | 20.83d → 7.83d |  | constraint start no earlier than 2016-04-05 → start no earlier than 2016-04-22 |
| 34 | Data logging | 2016-04-05 → 2016-04-22 (+17d) | 2016-04-05 → 2016-04-22 (+17d) |  |  | 20.33d → 7.33d |  | constraint start no earlier than 2016-04-05 → start no earlier than 2016-04-22 |
| 35 | Water alarm abort verification | 2016-04-05 A → 2016-04-22 A (+17d) | 2016-04-05 → 2016-04-22 (+17d) |  |  | 20.33d → 7.33d |  |  |
| 36 | Verify camera temperature reading | 2016-04-05 → 2016-04-22 (+17d) | 2016-04-05 → 2016-04-22 (+17d) |  |  | 20.33d → 7.33d |  | constraint start no earlier than 2016-04-05 → start no earlier than 2016-04-22 |
| 37 | Debug video peak and mean readings | 2016-04-05 → 2016-04-22 (+17d) | 2016-04-05 → 2016-04-22 (+17d) |  |  | 20.33d → 7.33d |  | constraint start no earlier than 2016-04-05 → start no earlier than 2016-04-22 |
| 38 | Lab unit testing complete | 2016-04-05 → 2016-04-22 (+17d) | 2016-04-05 → 2016-04-22 (+17d) |  |  | 20.33d → 7.33d |  |  |
| 39 | VM closed loop simulation testing | 2016-04-26 → 2016-05-04 (+8d) | 2016-04-28 → 2016-05-06 (+8d) |  |  | 6.33d → 0.33d |  |  |
| 40 | Code freeze | 2016-04-28 → 2016-05-06 (+8d) | 2016-04-28 → 2016-05-06 (+8d) |  |  | 6.33d → 0.33d |  |  |
| 41 | All lab testing complete | 2016-04-28 → 2016-05-06 (+8d) | 2016-04-28 → 2016-05-06 (+8d) |  |  | 6.33d → 0.33d |  |  |
| 42 | Assemble complete camera housing | 2016-05-06 → 2016-05-09 (+3d) | 2016-05-09 → 2016-05-10 (+1d) |  |  | 1.33d → 0.33d | 16, 41 → 41, 11 |  |
| 43 | **Tank testing with full vehicle running mission script** | 2016-05-09 → 2016-05-11 (+2d) | 2016-05-11 → 2016-05-13 (+2d) |  |  |  |  |  |
| 44 | Assemble full AUV system | 2016-05-09 → 2016-05-11 (+2d) | 2016-05-10 → 2016-05-11 (+1d) |  |  | 1.33d → 0d |  |  |
| 45 | Verify mission scripts | 2016-05-10 → 2016-05-12 (+2d) | 2016-05-11 → 2016-05-12 (+1d) |  |  | 1.33d → 0d |  |  |
| 46 | Confirm all camera operations | 2016-05-10 → 2016-05-12 (+2d) | 2016-05-11 → 2016-05-12 (+1d) |  |  | 1.33d → 0d |  |  |
| 47 | Verify lighting is optimized | 2016-05-11 → 2016-05-12 (+1d) | 2016-05-11 → 2016-05-12 (+1d) |  |  | 1d → 0d |  |  |
| 48 | Ballast and Trim | 2016-05-11 → 2016-05-12 (+1d) | 2016-05-11 → 2016-05-12 (+1d) |  |  | 1d → 0d |  |  |
| 49 | Tank testing complete | 2016-05-11 → 2016-05-12 (+1d) | 2016-05-11 → 2016-05-12 (+1d) |  |  | 1d → 0d |  |  |
| 50 | Load AUV for cruise | 2016-05-12 → 2016-05-13 (+1d) | 2016-05-12 → 2016-05-13 (+1d) |  |  | 1d → 0d |  |  |
| 51 | 1st transect intercomparison cruise |  |  |  |  |  |  | was named Cruise for transect mission |
