# I2MAP_EngineeringSchedule

How a schedule from MS Project changed from version to version. A marks actual dates.

## Version 1 (saved 2014-02-26, file I2MAP_EngineeringSchedule.mpp)

| ID | Task | Duration | Start | Finish | Predecessors | Complete | Total float | Constraint |
| --- | --- | --- | --- | --- | --- | --- | --- | --- |
| 1 | Capture draft of design requirements | 17.13d | 2014-01-01 A | 2014-01-27 |  | 85% | 159d |  |
| 2 | Research camera and recorder options | 19d | 2014-01-06 A | 2014-02-11 |  | 75% | 129.5d | start no earlier than 2014-01-06 |
| 3 | Select top three camera and recorder options | 2d | 2014-02-11 | 2014-02-13 | 2 |  | 129.5d |  |
| 4 | Document workflow path for each camera and recorder option | 3d | 2014-02-25 | 2014-02-28 | 3 |  | 134.5d |  |
| 5 | Document recorder and AUV interfaces for each camera option | 3d | 2014-02-20 | 2014-02-25 | 3 |  | 137.5d | start no earlier than 2014-01-26 |
| 6 | Investigate camera control interface for each camera option | 4d | 2014-02-11 | 2014-02-17 | 2 |  | 143.5d |  |
| 7 | Draft optical design specification and lens selection | 5d | 2014-02-13 | 2014-02-20 | 3 |  | 129.5d | start no earlier than 2014-01-29 |
| 8 | Identify optical consulant | 2d | 2014-03-05 | 2014-03-07 | 7 |  | 129.5d |  |
| 9 | Preliminary mechanical layout of lights, sensors and camera options | 3d | 2014-02-28 | 2014-03-05 | 7 |  | 131.5d |  |
| 10 | Concept design review | 0d | 2014-03-07 | 2014-03-07 | 3, 8, 1, 9, 5, 4, 6 |  | 129.5d |  |
| 11 | Design and construct camera test rig | 5d | 2014-03-07 | 2014-03-14 | 10 |  | 129.5d |  |
| 12 | Test three camera options | 10d | 2014-03-14 | 2014-03-28 | 11 |  | 129.5d |  |
| 13 | Evaluate camera test results | 5d | 2014-03-28 | 2014-04-04 | 12 |  | 129.5d |  |
| 14 | NAB Show | 5d | 2014-04-05 | 2014-04-10 |  |  |  | start no earlier than 2014-04-05 |
| 15 | Select optimal camera system | 2d | 2014-04-11 | 2014-04-14 | 13, 14 |  | 124d |  |
| 16 | Preliminary design review | 0d | 2014-04-14 | 2014-04-14 | 15, 14 |  | 124d |  |
| 17 | Specify AUV minimum speed | 0d | 2014-04-14 | 2014-04-14 | 15 |  | 174d |  |
| 18 | Complete system design | 5d | 2014-04-15 | 2014-04-21 | 15 |  | 169d |  |
| 19 | Final schematics for camera and sensor payload | 5d | 2014-04-15 | 2014-04-21 | 16 |  | 169d |  |
| 20 | Final Optical design | 10d | 2014-04-15 | 2014-04-28 | 16 |  | 124d |  |
| 21 | Housing mechanical design | 10d | 2014-04-15 | 2014-04-28 | 20FF |  | 124d |  |
| 22 | Purchase camera, lens, recorder and sensor instrumentation | 1.67d | 2014-04-29 | 2014-04-30 | 16, 21, 20 |  | 142.33d |  |
| 23 | Purchase cables and penetrators | 30d | 2014-01-01 | 2014-02-12 |  |  |  |  |
| 24 | Purchase and fabricate optical components | 20d | 2014-04-29 | 2014-05-26 | 20 |  | 124d |  |
| 25 | Fabricate mechanical components | 20d | 2014-04-29 | 2014-05-26 | 21 |  | 124d |  |
| 26 | Assemble and integrate complete nose cone | 10d | 2014-05-27 | 2014-06-09 | 25, 24, 22 |  | 124d |  |
| 27 | Complete system laboratory testing | 5d | 2014-06-10 | 2014-06-16 | 26 |  | 124d |  |
| 28 | Sea trials | 5d | 2014-06-17 | 2014-06-23 | 27 |  | 124d |  |
| 29 | Dorado Low Speed Testing - low bouyancy | 0d | 2014-03-12 | 2014-03-12 |  |  | 199d | start no earlier than 2014-03-12 |
| 30 | Dorado Low Speed Testing - winged | 0d | 2014-03-13 | 2014-03-13 |  |  | 198d | start no earlier than 2014-03-13 |
| 31 | Imaging AUV sea trial 1 | 0d | 2014-09-29 | 2014-09-29 |  |  | 55d | start no earlier than 2014-09-29 |
| 32 | Imaging AUV sea trial 2 | 0d | 2014-11-04 | 2014-11-04 |  |  | 29d | start no earlier than 2014-11-04 |
| 33 | Imaging AUV sea trial 3 | 0d | 2014-12-15 | 2014-12-15 |  |  | 0d | start no earlier than 2014-12-15 |

## Version 2 (saved 2014-08-20, file I2MAP_EngineeringScheduleVerKRR.mpp)

Last finish 2014-12-15 → 2014-12-17 (+2d). Complete tasks 0 → 12.

Added:

| ID | Task | Duration | Start | Finish | Predecessors | Constraint | Resources |
| --- | --- | --- | --- | --- | --- | --- | --- |
| 22 | Fabricate camera I/O adapter board | 15d | 2014-09-10 | 2014-09-30 | 21 |  | Mark Chaffey [60%]; E Tech |
| 23 | Contract optical design | 0d | 2014-09-03 | 2014-09-03 |  | must start on 2014-09-03 |  |
| 29 | Assemble camera housing | 3d | 2014-11-12 | 2014-11-14 | 22, 20, 26, 27, 28 |  | Mark Chaffey [60%]; François Cazenave [60%]; E Tech |
| 30 | Optical test housing and lighting | 3d | 2014-11-17 | 2014-11-19 | 29 |  | François Cazenave [60%]; Mark Chaffey [60%] |
| 31 | Pressure test housing | 2d | 2014-10-29 | 2014-10-30 | 28 |  | François Cazenave [60%] |

Removed: 14 NAB Show

Changed:

| ID | Task | Start | Finish | Duration | Complete | Total float | Predecessors | Other |
| --- | --- | --- | --- | --- | --- | --- | --- | --- |
| 1 | Capture draft of design requirements |  | 2014-01-27 A |  | 85% → 100% | 159d → none |  |  |
| 2 | Research camera and recorder options |  | 2014-02-11 A |  | 75% → 100% | 129.5d → none |  |  |
| 3 | Select top three camera and recorder options | 2014-02-11 A | 2014-02-13 A |  | 0% → 100% | 129.5d → none |  |  |
| 4 | Document workflow path for each camera and recorder option | 2014-02-25 A | 2014-02-28 A |  | 0% → 100% | 134.5d → none |  |  |
| 5 | Document recorder and AUV interfaces for each camera option | 2014-02-20 A | 2014-02-25 A |  | 0% → 100% | 137.5d → none |  |  |
| 6 | Investigate camera control interface for each camera option | 2014-02-11 A | 2014-02-17 A |  | 0% → 100% | 143.5d → none |  |  |
| 7 | Draft optical design specification and lens selection | 2014-02-13 A | 2014-02-20 A |  | 0% → 100% | 129.5d → none |  |  |
| 8 | Identify optical consulant | 2014-03-05 → 2014-08-11 (+159d) | 2014-03-07 → 2014-08-12 (+158d) |  |  | 129.5d → 38d |  | constraint none → start no earlier than 2014-08-10 |
| 9 | Preliminary mechanical layout of lights, sensors and camera options | 2014-02-28 A | 2014-03-05 A |  | 0% → 100% | 131.5d → none |  |  |
| 10 | Concept design review | 2014-03-07 → 2014-04-24 (+48d) | 2014-03-07 → 2014-04-24 (+48d) |  |  | 129.5d → 167d | 3, 8, 1, 9, 5, 4, 6 → 3, 1, 9, 5, 4, 6 | constraint none → start no earlier than 2014-04-24 |
| 13 | Design and construct camera test rig | 2014-03-07 → 2014-06-09 A (+94d) | 2014-03-14 → 2014-06-13 A (+91d) |  | 0% → 100% | 129.5d → none |  | constraint none → finish no earlier than 2014-06-13 |
| 14 | Test three camera options | 2014-03-14 → 2014-06-16 A (+94d) | 2014-03-28 → 2014-07-18 A (+112d) | 10d → 25d | 0% → 100% | 129.5d → none |  |  |
| 15 | Evaluate camera test results | 2014-03-28 → 2014-07-21 A (+115d) | 2014-04-04 → 2014-07-25 (+112d) |  | 0% → 75% | 129.5d → 100d |  | constraint none → finish no earlier than 2014-07-22 |
| 16 | Select optimal camera system | 2014-04-11 → 2014-07-28 A (+108d) | 2014-04-14 → 2014-07-29 A (+106d) |  | 0% → 100% | 124d → none | 15, NAB Show → 15 |  |
| 17 | Complete system design | 2014-04-15 → 2014-07-30 A (+106d) | 2014-04-21 → 2014-08-15 A (+116d) | 5d → 13d | 0% → 100% | 169d → none |  |  |
| 18 | Specify AUV minimum speed | 2014-04-14 → 2014-07-29 (+106d) | 2014-04-14 → 2014-07-29 (+106d) |  |  | 174d → 98d |  |  |
| 19 | Preliminary design review | 2014-04-14 → 2014-08-20 (+128d) | 2014-04-14 → 2014-08-20 (+128d) |  |  | 124d → 33d | 16, NAB Show → 16, 8, 17 | constraint none → start no earlier than 2014-08-20 |
| 20 | Purchase camera, lens, recorder and sensor instrumentation | 2014-04-29 → 2014-08-20 (+113d) | 2014-04-30 → 2014-09-23 (+146d) | 1.67d → 25d |  | 142.33d → 35d | 19, 25, 24 → 19 |  |
| 21 | Final schematics for camera and sensor payload | 2014-04-15 → 2014-08-20 (+127d) | 2014-04-21 → 2014-09-09 (+141d) | 5d → 15d |  | 169d → 15d |  | resources none → Mark Chaffey [60%] |
| 24 | Final Optical design | 2014-04-15 → 2014-09-03 (+141d) | 2014-04-28 → 2014-09-30 (+155d) | 10d → 20d |  | 124d → 0d | 19 → 19, 23 | resources Mark Chaffey [60%] → Mark Chaffey [20%]; Consultant; François Cazenave [40%] |
| 25 | Housing mechanical design | 2014-04-15 → 2014-09-10 (+148d) | 2014-04-28 → 2014-09-30 (+155d) | 10d → 15d |  | 124d → 10d |  |  |
| 26 | Purchase cables and penetrators | 2014-01-01 → 2014-09-10 (+252d) | 2014-02-12 → 2014-10-21 (+251d) |  |  |  | none → 21 | resources none → Mark Chaffey [60%] |
| 27 | Purchase and fabricate optical components | 2014-04-29 → 2014-10-01 (+155d) | 2014-05-26 → 2014-11-11 (+169d) | 20d → 30d |  | 124d → 0d |  |  |
| 28 | Fabricate mechanical components | 2014-04-29 → 2014-10-01 (+155d) | 2014-05-26 → 2014-10-28 (+155d) |  |  | 124d → 10d |  |  |
| 32 | Assemble and integrate complete nose cone | 2014-05-27 → 2014-11-20 (+177d) | 2014-06-09 → 2014-12-03 (+177d) |  |  | 124d → 0d | 28, 27, 20 → 28, 27, 20, 31, 30 |  |
| 33 | Complete system laboratory testing | 2014-06-10 → 2014-12-04 (+177d) | 2014-06-16 → 2014-12-10 (+177d) |  |  | 124d → 0d |  | resources Kim Reisenbichler; Mark Chaffey [60%]; AUV tech → Kim Reisenbichler; Mark Chaffey [60%]; AUV tech; Rich Henthorn [60%] |
| 34 | Sea trials | 2014-06-17 → 2014-12-11 (+177d) | 2014-06-23 → 2014-12-17 (+177d) |  |  | 124d → 0d |  |  |
| 35 | Imaging AUV sea trial 1--> 2 knot Stability Test |  |  |  |  | 55d → 58d |  | was named Imaging AUV sea trial 1 |
| 36 | Imaging AUV sea trial 2 -->ROV base Cam Testing |  |  |  |  | 29d → 32d |  | was named Imaging AUV sea trial 2 |
| 37 | Imaging AUV sea trial 3-->First System Sea Trial |  |  |  |  | 0d → 3d |  | was named Imaging AUV sea trial 3 |
